# Lançamento comercial do produto

Schedule from MS Project, 2006-11-13 to 2007-01-08, costs in R$, A marks actual dates.
UFPE
Projeto de exemplo para fixação do treinamento

## Calendars

- Produção: Mon-Sat 09:00-13:00, 14:00-18:00; Sun off. Exceptions (off unless hours are given): 2006-11-15, 2006-11-21 09:00-13:00, 14:00-18:00, 2006-12-08, 2006-12-17 to 2006-12-21 09:00-13:00, 14:00-19:00, 2006-12-23 09:00-13:00, 2006-12-25, 2006-12-26 to 2006-12-28 09:00-13:00, 14:00-19:00, 2006-12-30 09:00-13:00, 2006-12-31.
- Reuniões: Mon-Sat 09:00-13:00, 14:00-19:00; Sun off. Exceptions (off unless hours are given): 2006-11-15, 2006-11-21 09:00-13:00, 14:00-19:00, 2006-12-08, 2006-12-17 to 2006-12-21 09:00-13:00, 14:00-22:00, 2006-12-23 09:00-13:00, 2006-12-25, 2006-12-26 to 2006-12-28 09:00-13:00, 14:00-22:00, 2006-12-30 09:00-13:00, 2006-12-31.

## Resources

| Resource | Group | Unit | Rate | Cost per use |
| --- | --- | --- | --- | --- |
| Diretor | DIR |  | 50 |  |
| Secretária | DIR |  | 12 |  |
| Ger. Executivo | PRO |  | 18 |  |
| Ger. Administrativo | ADM |  | 16 |  |
| Produção | PRO |  | 6 |  |
| Quimico | PRO |  | 12 |  |
| Distibuidor | Ampla |  | 6 |  |
| Ag. Publicidade | AMpla |  | 11.3 |  |
| Vendedor | MKT |  | 8 |  |
| Caminhão | EQP |  | 3 |  |
| Motorista | PRO |  | 12 |  |
| Ajudante | PRO |  | 4 |  |
| Reagente | MAT | Galões | 1.3 |  |
| Kit de Limpeza | MAT | Conjuntos |  | 800 |

## Schedule

| ID | WBS | Task | Type | Duration | Start | Finish | Predecessors | Complete | Remaining | Total slack | Free slack | Constraint | Calendar | Resources | Work | Actual work | Cost | Actual cost |
| --- | --- | --- | --- | --- | --- | --- | --- | --- | --- | --- | --- | --- | --- | --- | --- | --- | --- | --- |
| 1 | 1 | **Lançamento Comercial de produto** |  | 46.94d | 2006-11-13 A | 2007-01-08 |  | 12% | 41.34d | 0d |  |  |  |  | 16855h | 88h | 151,809.8 | 1,184 |
| 2 | 1.1 | **Rotinas da Administração** |  | 46.94d | 2006-11-13 A | 2007-01-08 |  | 23% | 36.25d | 0d |  |  |  |  | 3711h | 88h | 63,438 | 1,184 |
| 3 | 1.1.1 | Comunicar Metas |  | 1.5h | 2006-11-13 | 2006-11-13 |  |  |  | 0d |  |  |  | Diretor [300%]; Secretária [300%]; Ger. Executivo; Ger. Administrativo | 12h |  | 330 |  |
| 4 | 1.1.2 | Providenciar Registro |  | 4d | 2006-11-13 A | 2006-11-20 A | 3 | 100% |  |  |  |  |  | Secretária; Ger. Administrativo | 64h | 64h | 896 | 896 |
| 5 | 1.1.3 | Contatar Veículo Propaganda |  | 3d | 2006-11-13 A | 2006-11-17 A | 3 | 100% |  |  |  |  |  | Secretária | 24h | 24h | 288 | 288 |
| 6 | 1.1.4 | Comprar Material de Propaganda | milestone | 0d | 2006-11-13 A | 2006-11-13 | 3 | 33% | 0d | 12.06d | 0d |  |  | Secretária; Ger. Administrativo | 8h |  | 144 |  |
| 7 | 1.1.5 | Discutir Vendas |  | 3d | 2006-11-17 | 2006-11-22 | 5, 6 |  |  | 40d | 20.75d |  | Reuniões | Secretária; Vendedor [1200%]; Distibuidor [10000%] | 2401h |  | 14,408 |  |
| 8 | 1.1.6 | Reavaliar Processos |  | 4.5h | 2006-12-16 | 2006-12-17 | 4, 7, 25 |  |  | 13.19d | 0d |  |  | Diretor [200%]; Secretária [200%]; Ger. Executivo | 20h |  | 568 |  |
| 9 | 1.1.7 | Discutir Lançamento |  | 18h | 2006-12-17 | 2006-12-19 | 8 |  |  | 16.06d | 13.19d |  | Reuniões | Diretor [300%]; Secretária [200%]; Ger. Administrativo; Ger. Executivo | 96h |  | 2,640 |  |
| 10 | 1.1.8 | Conferir material propaganda |  | 6h | 2006-11-23 | 2006-11-23 | 6FS+8d |  |  | 12.06d | 0d |  |  | Secretária | 6h |  | 2,572 |  |
| 11 | 1.1.9 | Distribuir material propaganda |  | 2d | 2006-12-16 | 2006-12-18 | 10 |  |  | 14d |  |  |  | Motorista [1200%]; Caminhão [1200%] | 384h |  | 2,880 |  |
| 12 | 1.1.10 | Veicular comercial |  | 3d | 2007-01-01 | 2007-01-04 | 5 |  |  | 0d |  | as late as possible |  | Ag. Publicidade | 24h |  | 12,271.2 |  |
| 13 | 1.1.11 | Lançar Produto |  | 4ed | 2007-01-04 | 2007-01-08 | 9, 11, 12, 21 |  |  | 0d |  |  |  | Diretor [300%]; Secretária [300%]; Ag. Publicidade | 672h |  | 26,440.8 |  |
| 14 | 1.2 | **Rotinas de Produção** |  | 43.75d | 2006-11-13 | 2007-01-04 |  |  |  | 0d |  |  |  |  | 4272h |  | 26,832 |  |
| 15 | 1.2.1 | Produzir Protótipo |  | 5d | 2006-11-13 | 2006-11-20 | 3 |  |  | 0d |  |  |  | Ger. Executivo; Produção [2500%] | 1040h |  | 6,720 |  |
| 16 | 1.2.2 | Produzir Produto |  | 0.17d | 2006-12-14 | 2006-12-15 | 24 |  |  | 0d |  |  |  | Produção [8000%] | 112h |  | 672 |  |
| 17 | 1.2.3 | Produzir Embalagem |  | 8d | 2006-12-14 | 2006-12-22 | 16SS |  |  | 0d |  |  |  | Produção [2000%] | 1280h |  | 7,680 |  |
| 18 | 1.2.4 | Pronto para Embalar | milestone | 0d | 2006-12-22 | 2006-12-22 | 16, 17 |  |  | 0d |  |  |  |  |  |  |  |  |
| 19 | 1.2.5 | Embalar |  | 6d | 2006-12-22 | 2006-12-30 | 18 |  |  | 0d |  |  |  | Ger. Executivo; Produção [2500%] | 1248h |  | 8,064 |  |
| 20 | 1.2.6 | Carregar |  | 2d | 2006-12-30 | 2007-01-02 | 19 |  |  | 0d |  |  |  | Caminhão [1200%]; Motorista [1200%]; Ajudante [1200%] | 576h |  | 3,648 |  |
| 21 | 1.2.7 | Distribuir |  | 2d | 2007-01-02 | 2007-01-04 | 20 |  |  | 0d |  |  |  | Caminhão | 16h |  | 48 |  |
| 22 | 1.3 | **Teste de Qualidade** |  | 22.75d | 2006-11-20 | 2006-12-16 |  |  |  | 0d |  |  |  | Caminhão [1200%]; Motorista [1200%]; Ajudante [1200%]; Vendedor [1200%] | 8872h |  | 61,539.8 |  |
| 23 | 1.3.1 | Colher/testar Amostra |  | 6h | 2006-11-20 | 2006-11-20 | 15 |  |  | 0d |  |  |  | Ger. Executivo; Quimico [300%]; Reagente [6 Galões]; Kit de Limpeza [1 Conjuntos] | 24h |  | 1,131.8 |  |
| 24 | 1.3.2 | Analisar Resultados |  | 2d | 2006-12-12 | 2006-12-14 | 23FS+18d |  |  | 0d |  |  |  | Quimico [300%] | 48h |  | 576 |  |
| 25 | 1.3.3 | Redigir Relatório Técnico |  | 2d | 2006-12-14 | 2006-12-16 | 24 |  |  | 13.25d | 0d |  |  | Ger. Executivo; Quimico [300%] | 64h |  | 864 |  |
